# Simple Assignments

Schedule from MS Project, 2012-01-02 to 2012-02-28.
New book launch schedule
Lucerne Publishing

## Calendars

- Standard: Mon-Fri 08:00-12:00, 13:00-17:00; Sat-Sun off. Exceptions (off unless hours are given): 2012-01-19 (Staff at morale event).

## Resources

| Resource | Rate | Notes |
| --- | --- | --- |
| Jun Cao | 42 |  |
| Sharon Salavaria | 27.5 | Sharon's standard pay rate is adjusted for her half-time work schedule. |
| Toby Nixon | 67.5 | Toby worked on launch campaigns for Toni Poe's previous two books. |
| Toni Poe |  |  |
| Zac Woodall | 55 |  |
| Copyeditors | 45 |  |
| Travel |  |  |
| Carole Poland | 52.5 |  |
| Dan Jump | 75.5 |  |
| Hany Morcos | 38.75 |  |
| Jane Dow | 55 |  |
| John Evans | 69.5 |  |
| Katie Jordan | 48 |  |
| Luis Sousa | 70 |  |
| Printing Service |  |  |
| Robin Wood | 44 |  |
| Vikas Jain | 22 |  |
| William Flash |  |  |

## Schedule

| ID | WBS | Task | Type | Duration | Start | Finish | Predecessors | Total slack | Free slack |
| --- | --- | --- | --- | --- | --- | --- | --- | --- | --- |
| 1 | 1 | **Planning Phase** |  | 11d | 2012-01-02 | 2012-01-16 |  | 0d |  |
| 2 | 1.1 | Assign launch team members |  | 1d | 2012-01-02 | 2012-01-02 |  | 0d |  |
| 3 | 1.2 | Complete author questionnaire |  | 1w | 2012-01-03 | 2012-01-09 | 2 | 5d |  |
| 4 | 1.3 | Schedule author interviews |  | 1w | 2012-01-03 | 2012-01-09 | 2 | 5d |  |
| 5 | 1.4 | Design and order marketing material |  | 2w | 2012-01-03 | 2012-01-16 | 2 | 0d |  |
| 6 | 1.5 | Planning complete! | milestone | 0d | 2012-01-16 | 2012-01-16 | 5 | 0d |  |
| 7 | 2 | **Internal Launch Phase** |  | 18d | 2012-01-17 | 2012-02-10 | 1 | 0d |  |
| 8 | 2.1 | Kickoff book launch meeting |  | 1d | 2012-01-17 | 2012-01-17 |  | 0d |  |
| 9 | 2.2 | Plan author's travel itinerary |  | 3d | 2012-01-18 | 2012-01-23 | 8 | 14d |  |
| 10 | 2.3 | Channel Sales prep |  | 2w | 2012-01-18 | 2012-02-01 | 8 | 0d |  |
| 11 | 2.4 | Complete book launch form |  | 2d | 2012-02-02 | 2012-02-03 | 10 | 5d |  |
| 12 | 2.5 | Prepare book sales kit |  | 1w | 2012-02-02 | 2012-02-08 | 8, 10 | 0d |  |
| 13 | 2.6 | Distribute internal marketing material |  | 2d | 2012-02-09 | 2012-02-10 | 12 | 0d |  |
| 14 | 3 | **Public Launch Phase** |  | 12d | 2012-02-13 | 2012-02-28 | 7 | 0d |  |
| 15 | 3.1 | **Author travel and appearances** |  | 2d | 2012-02-13 | 2012-02-14 |  | 10d |  |
| 16 | 3.1.1 | Author radio interview |  | 1d | 2012-02-13 | 2012-02-13 |  | 10d | 0d |
| 17 | 3.1.2 | Author reading and signing at book fair |  | 1d | 2012-02-14 | 2012-02-14 | 16 | 10d |  |
| 18 | 3.2 | Distribute advance copies |  | 2d | 2012-02-13 | 2012-02-14 |  | 10d |  |
| 19 | 3.3 | Distribute book sales kit |  | 2d | 2012-02-13 | 2012-02-14 |  | 0d |  |
| 20 | 3.4 | Coordinate magazine feature articles |  | 7d | 2012-02-15 | 2012-02-23 | 19 | 3d |  |
| 21 | 3.5 | Launch public Web portal for book |  | 1w | 2012-02-15 | 2012-02-21 | 19 | 0d |  |
| 22 | 3.6 | Launch social media programs for book |  | 1w | 2012-02-22 | 2012-02-28 | 21 | 0d |  |
| 23 | 3.7 | Launch complete! | milestone | 0d | 2012-02-28 | 2012-02-28 | 20, 21, 22 | 0d |  |

Notes:
- 18: Get recipient list from publicist
